# JunkProject

Schedule from MS Project, 2001-11-23 to 2002-03-26, costs in $.
Test project for learning MS Project
William Horton Consulting, Inc.

## Calendars

- Standard: Mon 09:00-12:00, 13:00-17:00; Tue-Thu 08:00-12:00, 13:00-18:00; Fri 08:00-12:00, 13:00-16:00; Sat-Sun off.

## Resources

| Resource | Group | Rate |
| --- | --- | --- |
| Manager of training dept | People |  |
| Manager of parallel dept | People | 50 |
| Manager of sales | People | 60 |
| Director of human resources | People | 80 |
| Facilitator | People | 40 |

## Schedule

| ID | WBS | Task | Type | Duration | Start | Finish | Predecessors | Total slack | Resources | Work | Cost |
| --- | --- | --- | --- | --- | --- | --- | --- | --- | --- | --- | --- |
| 1 | 1 | **Develop plan** |  | 19d | 2001-11-23 | 2001-12-19 |  | 0d |  | 176h | 8,800 |
| 2 | 1.1 | Set evaluation goals |  | 1w | 2001-11-23 | 2001-11-29 |  | 0d | Manager of training dept | 40h | 2,000 |
| 3 | 1.2 | Plan data collection |  | 3d | 2001-11-29 | 2001-12-04 | 2 | 1d | Manager of training dept | 24h | 1,200 |
| 4 | 1.3 | Plan analysis |  | 4d | 2001-11-29 | 2001-12-05 | 2, 3FF | 0d | Manager of training dept | 32h | 1,600 |
| 5 | 1.4 | Set budget |  | 3d | 2001-12-05 | 2001-12-10 | 3, 4 | 0d | Manager of training dept | 24h | 1,200 |
| 6 | 1.5 | Write up plan |  | 2d | 2001-12-11 | 2001-12-12 | 5 | 0d | Manager of training dept | 16h | 800 |
| 7 | 1.6 | Have plan approved |  | 1w | 2001-12-12 | 2001-12-19 | 6 | 0d | Manager of training dept | 40h | 2,000 |
| 8 | 2 | Go ahead | milestone | 0d | 2001-12-19 | 2001-12-19 | 7 | 0d | Director of human resources |  |  |
| 9 | 3 | **Prepare for training** |  | 4d | 2001-12-19 | 2001-12-25 |  | 0d |  | 72h | 3,400 |
| 10 | 3.1 | Recruit learners |  | 2d | 2001-12-19 | 2001-12-21 | 8 | 0d | Manager of training dept | 16h | 800 |
| 11 | 3.2 | Gather preclass data |  | 2d | 2001-12-21 | 2001-12-25 | 10 | 0d | Manager of training dept | 16h | 800 |
| 12 | 3.3 | Prepare facilitator |  | 2.5d | 2001-12-19 | 2001-12-24 | 8 | 1.5d | Manager of training dept; Facilitator | 40h | 1,800 |
| 13 | 4 | Conduct training |  | 2w | 2001-12-25 | 2002-01-08 | 11, 12 | 0d | Facilitator | 80h | 3,200 |
| 14 | 5 | **Gather postclass data** |  | 32.5d | 2002-01-08 | 2002-02-20 |  | 24d |  | 48h | 2,600 |
| 15 | 5.1 | Gather end-of-class data |  | 1d | 2002-01-08 | 2002-01-09 | 13 | 55.5d | Manager of training dept | 8h | 400 |
| 16 | 5.2 | Gather job-performance data |  | 0.5w | 2002-02-18 | 2002-02-20 | 13FS+30d | 0d | Manager of training dept; Manager of sales | 40h | 2,200 |
| 17 | 6 | All data collected | milestone | 0d | 2002-02-20 | 2002-02-20 | 16 | 0d |  |  |  |
| 18 | 7 | **Analyze data** |  | 5d | 2002-02-21 | 2002-02-27 |  | 0d |  | 40h | 2,000 |
| 19 | 7.1 | Convert to numeric measures |  | 3d | 2002-02-21 | 2002-02-26 | 17 | 0d | Manager of parallel dept | 24h | 1,200 |
| 20 | 7.2 | Compute statistics |  | 2d | 2002-02-26 | 2002-02-27 | 19 | 0d | Manager of parallel dept | 16h | 800 |
| 21 | 8 | **Report results** |  | 18d | 2002-02-27 | 2002-03-25 |  | 0d |  | 144h | 7,200 |
| 22 | 8.1 | Prepare tables and graphs |  | 3d | 2002-02-27 | 2002-03-04 | 20 | 0d | Manager of training dept | 24h | 1,200 |
| 23 | 8.2 | Draft report |  | 1w | 2002-03-05 | 2002-03-11 | 22 | 0d | Manager of training dept | 40h | 2,000 |
| 24 | 8.3 | Have report reviewed |  | 1w | 2002-03-11 | 2002-03-18 | 23 | 0d | Manager of training dept | 40h | 2,000 |
| 25 | 8.4 | Revise report |  | 2d | 2002-03-18 | 2002-03-20 | 24 | 0d | Manager of training dept | 16h | 800 |
| 26 | 8.5 | Publish report |  | 3d | 2002-03-20 | 2002-03-25 | 25 | 0d | Manager of training dept | 24h | 1,200 |

Notes:
- 2: Get information about the specific objectives of the course and translate these into goals for the evaluation process.

| ID | WBS | Task | Type | Duration | Start | Finish | Predecessors | Total slack | Resources | Work | Cost |
| --- | --- | --- | --- | --- | --- | --- | --- | --- | --- | --- | --- |
| 27 | 9 | **Present results** |  | 16d | 2002-03-05 | 2002-03-26 |  | 0d |  | 40h | 2,000 |
| 28 | 9.1 | Prepare presentation |  | 4d | 2002-03-05 | 2002-03-08 | 22 | 11d | Manager of training dept | 32h | 1,600 |
| 29 | 9.2 | Conduct presentation |  | 1d | 2002-03-25 | 2002-03-26 | 28, 26 | 0d | Manager of training dept | 8h | 400 |
| 30 | 10 | Project done | milestone | 0d | 2002-03-26 | 2002-03-26 | 29 | 0d |  |  |  |
